# PFCMP.a3

How a schedule from MS Project changed from version to version. A marks actual dates.

## Version 1 (data date 2002-10-31, saved 2001-11-29, file MP Escenario 3-1.mpp)

| ID | WBS | Task | Duration | Start | Finish | Predecessors | Complete | Total float | Constraint |
| --- | --- | --- | --- | --- | --- | --- | --- | --- | --- |
| 1 | 1 | **PROYECTO** | 342.05d | 2002-01-02 A | 2003-05-15 |  | 72% | 0d |  |
| 2 |  | Dirección de proyecto 1 | 342d | 2002-01-02 A | 2003-05-14 |  | 62% | 0.05d |  |
| 3 | 1.2 | **INGENIERÍA** | 75d | 2002-01-02 A | 2002-04-19 A |  | 100% |  |  |
| 4 |  | Ingeniería Básica | 30d | 2002-01-02 A | 2002-02-12 A |  | 100% |  |  |
| 5 |  | Ingeniería Básica del edificio | 20d | 2002-02-13 A | 2002-03-12 A | 4 | 100% |  |  |
| 6 |  | Ingeniería de proceso | 45d | 2002-02-13 A | 2002-04-19 A | 4 | 100% |  |  |
| 7 | 1.3 | **INGENIERÍA DE DETALLE** | 105d | 2002-03-13 A | 2002-08-12 A |  | 100% |  |  |
| 8 |  | Ing. Detalle estructuras y arquitectura | 30d | 2002-04-15 A | 2002-05-27 A | 5 | 100% |  |  |
| 9 |  | Ing. Detalle motogeneradores (especs) | 30d | 2002-04-22 A | 2002-06-03 A | 6 | 100% |  |  |
| 10 |  | Ing. Detalle tuberías y equipos auxiliares | 50d | 2002-06-04 A | 2002-08-12 A | 6 | 100% |  |  |
| 11 |  | Ing. Detalle eléctrica | 50d | 2002-04-22 A | 2002-07-01 A | 6 | 100% |  |  |
| 12 |  | Ing. Detalle instrumentación y control | 50d | 2002-04-22 A | 2002-07-01 A | 6 | 100% |  |  |
| 13 |  | Ing. Detalle explanación y cimentaciones | 20d | 2002-03-13 A | 2002-04-12 A | 5 | 100% |  |  |
| 14 | 1.4 | **SUMINISTRO** | 130.63d | 2002-06-04 A | 2002-12-05 |  | 95% | 106.42d |  |
| 15 |  | Suministro equipos auxiliares | 40d | 2002-08-13 A | 2002-10-08 A | 10 | 100% |  |  |
| 16 |  | pago entrega planos ea | 1d | 2002-08-30 A | 2002-08-30 A | 15SS+3% | 100% |  |  |
| 17 |  | pago planos definitivos ea | 1d | 2002-09-11 A | 2002-09-11 A | 15SS+20d | 100% |  |  |
| 18 |  | pago entrega ea | 1d | 2002-10-08 A | 2002-10-08 A | 15FF | 100% |  |  |
| 19 |  | pago satisfactorio ea | 1d | 2002-10-29 A | 2002-10-29 A | 15FF+15d | 100% |  |  |
| 20 |  | Suministro motogeneradores | 90d | 2002-06-04 A | 2002-10-08 A | 9 | 100% |  |  |
| 21 |  | pago entrega planos m | 1d | 2002-07-08 A | 2002-07-08 A | 20SS+3% | 100% |  |  |
| 22 |  | pago planos definitivos m | 1d | 2002-08-06 A | 2002-08-06 A | 20SS+5% | 100% |  |  |
| 23 |  | pago entrega m | 1d | 2002-10-08 A | 2002-10-08 A | 20FF | 100% |  |  |
| 24 |  | pago satisfactorio m | 1d | 2002-10-29 A | 2002-10-29 A | 20FF+15d | 100% |  |  |
| 25 |  | Suministro tuberías y accesorios | 50d | 2002-09-04 A | 2002-11-14 | 10 | 83% | 0d | as late as possible |
| 26 |  | pago entrega planos ta | 1d | 2002-09-25 A | 2002-09-26 A | 25SS+3% | 100% |  |  |
| 27 |  | pago planos definitivos ta | 1d | 2002-10-09 A | 2002-10-10 A | 25SS+25d | 100% |  |  |
| 28 |  | pago entrega ta | 1d | 2002-11-13 | 2002-11-14 | 25FF |  | 121.42d |  |
| 29 |  | pago satisfactorio ta | 1d | 2002-12-04 | 2002-12-05 | 25FF+15d |  | 106.42d |  |
| 30 |  | Suministro equipos eléctricos | 60d | 2002-08-13 A | 2002-11-06 | 11FS+30d | 95% | 38.96d |  |
| 31 |  | pago entrega planos ee | 1d | 2002-09-09 A | 2002-09-09 A | 30SS+3% | 100% |  |  |
| 32 |  | pago planos definitivos ee | 1d | 2002-09-25 A | 2002-09-25 A | 30SS+30d | 100% |  |  |
| 33 |  | pago entrega ee | 1d | 2002-11-06 | 2002-11-06 | 30FF |  | 127.05d |  |
| 34 |  | pago satisfactorio ee | 1d | 2002-11-27 | 2002-11-27 | 30FF+15d |  | 112.05d |  |
| 35 |  | Suministro instrumentación y sist. Control | 50d | 2002-07-02 A | 2002-09-10 A | 12 | 100% |  |  |
| 36 |  | pago entrega planos isc | 1d | 2002-07-23 A | 2002-07-23 A | 35SS+3% | 100% |  |  |
| 37 |  | pago planos definitivos isc | 1d | 2002-08-06 A | 2002-08-06 A | 35SS+25d | 100% |  |  |
| 38 |  | pago entrega isc | 1d | 2002-09-10 A | 2002-09-10 A | 35FF | 100% |  |  |
| 39 |  | pago satisfactorio isc | 1d | 2002-10-01 A | 2002-10-01 A | 35FF+15d | 100% |  |  |
| 40 | 1.5 | **CONSTRUCCION Y MONTAJE** | 218d | 2002-04-15 A | 2003-02-21 |  | 62% | 54.05d |  |
| 41 |  | Dirección de construcción | 218d | 2002-04-15 A | 2003-02-21 | 42SS | 65% | 54.05d |  |
| 42 |  | Explanación y construcción cimentaciones | 45d | 2002-04-15 A | 2002-06-17 A | 13 | 100% |  |  |
| 43 |  | Construcción estructura edificio | 65d | 2002-06-18 A | 2002-10-08 A | 8, 42 | 100% |  |  |
| 44 |  | Cerramientos y acabados | 40d | 2002-10-09 A | 2002-12-04 | 43 | 43% | 97.05d |  |
| 45 |  | Montaje motogeneradores | 25.63d | 2002-10-09 A | 2002-11-14 | 20, 42 | 66% | 0d |  |
| 46 |  | Montaje tuberías y equipos auxiliares | 33.33d | 2002-11-14 | 2003-01-03 | 45, 15, 25 |  | 0d |  |
| 47 |  | Montaje electricidad e instrumentación | 33.09d | 2003-01-03 | 2003-02-21 | 30, 35, 46 |  | 0d |  |
| 48 | 1.6 | **PRUEBAS Y PUESTA EN SERVICIO** | 88.09d | 2003-01-03 | 2003-05-15 |  |  | 0d |  |
| 49 |  | Pruebas equipos en vacío | 15d | 2003-02-03 | 2003-02-24 | 50, 45 |  | 13.09d |  |
| 50 |  | Pruebas hidraúlicas tuberías y equipos | 20d | 2003-01-03 | 2003-02-03 | 46 |  | 13.09d |  |
| 51 |  | Pruebas eléctricas | 15d | 2003-02-21 | 2003-03-14 | 47 |  | 0d |  |
| 52 |  | Pruebas instrumentos y sist control | 15d | 2003-02-21 | 2003-03-14 | 47 |  | 0d |  |
| 53 |  | Puesta en marcha | 20d | 2003-03-14 | 2003-04-16 | 49, 51, 52 |  | 0d |  |
| 54 |  | Puesta en operación | 10d | 2003-04-16 | 2003-04-30 | 53 |  | 0d |  |
| 55 |  | Garantías y recepción | 10d | 2003-04-30 | 2003-05-15 | 54, 44 |  | 0d |  |

## Version 2 (data date 2002-04-30, saved 2001-11-29, file MP Escenario 1-1.mpp)

Last finish 2003-05-15 → 2003-05-12 (-3d). Complete tasks 30 → 4.

Changed:

| ID | Task | Start | Finish | Duration | Complete | Total float | Predecessors | Other |
| --- | --- | --- | --- | --- | --- | --- | --- | --- |
| 1 | **PROYECTO** |  | 2003-05-15 → 2003-05-12 (-3d) | 342.05d → 340d | 72% → 17% |  |  |  |
| 2 | Dirección de proyecto 1 |  | 2003-05-14 → 2003-05-12 (-2d) | 342d → 340d | 62% → 24% | 0.05d → 0d |  |  |
| 7 | **INGENIERÍA DE DETALLE** |  | 2002-08-12 A → 2002-08-12 |  | 100% → 23% | none → 185d |  |  |
| 8 | Ing. Detalle estructuras y arquitectura |  | 2002-05-27 A → 2002-05-27 |  | 100% → 40% | none → 140d |  |  |
| 9 | Ing. Detalle motogeneradores (especs) |  | 2002-06-03 A → 2002-06-03 |  | 100% → 23% | none → 0d |  |  |
| 10 | Ing. Detalle tuberías y equipos auxiliares | 2002-06-04 A → 2002-06-04 | 2002-08-12 A → 2002-08-12 |  | 100% → 0% | none → 0d |  |  |
| 11 | Ing. Detalle eléctrica |  | 2002-07-01 A → 2002-07-01 |  | 100% → 14% | none → 60d |  |  |
| 12 | Ing. Detalle instrumentación y control |  | 2002-07-01 A → 2002-07-01 |  | 100% → 14% | none → 70d |  |  |
| 14 | **SUMINISTRO** | 2002-06-04 A → 2002-06-04 | 2002-12-05 → 2002-11-13 (-22d) | 130.63d → 115d | 95% → 0% | 106.42d → 0d |  |  |
| 15 | Suministro equipos auxiliares | 2002-08-13 A → 2002-08-13 | 2002-10-08 A → 2002-10-08 |  | 100% → 0% | none → 10d |  |  |
| 16 | pago entrega planos ea | 2002-08-30 A → 2002-08-30 | 2002-08-30 A → 2002-08-30 |  | 100% → 0% | none → 172d |  |  |
| 17 | pago planos definitivos ea | 2002-09-11 A → 2002-09-11 | 2002-09-11 A → 2002-09-11 |  | 100% → 0% | none → 164d |  |  |
| 18 | pago entrega ea | 2002-10-08 A → 2002-10-08 | 2002-10-08 A → 2002-10-08 |  | 100% → 0% | none → 145d |  |  |
| 19 | pago satisfactorio ea | 2002-10-29 A → 2002-10-29 | 2002-10-29 A → 2002-10-29 |  | 100% → 0% | none → 130d |  |  |
| 20 | Suministro motogeneradores | 2002-06-04 A → 2002-06-04 | 2002-10-08 A → 2002-09-24 (-14d) | 90d → 80d | 100% → 0% | none → 0d |  |  |
| 21 | pago entrega planos m | 2002-07-08 A → 2002-07-08 | 2002-07-08 A → 2002-07-08 |  | 100% → 0% | none → 210d |  |  |
| 22 | pago planos definitivos m | 2002-08-06 A → 2002-07-30 (-7d) | 2002-08-06 A → 2002-07-30 (-7d) |  | 100% → 0% | none → 194d | 20SS+5% → 20SS+40d |  |
| 23 | pago entrega m | 2002-10-08 A → 2002-09-24 (-14d) | 2002-10-08 A → 2002-09-24 (-14d) |  | 100% → 0% | none → 155d |  |  |
| 24 | pago satisfactorio m | 2002-10-29 A → 2002-10-15 (-14d) | 2002-10-29 A → 2002-10-15 (-14d) |  | 100% → 0% | none → 140d |  |  |
| 25 | Suministro tuberías y accesorios | 2002-09-04 A → 2002-08-13 (-22d) | 2002-11-14 → 2002-10-22 (-23d) |  | 83% → 0% |  |  | constraint as late as possible → none |
| 26 | pago entrega planos ta | 2002-09-25 A → 2002-09-04 (-21d) | 2002-09-26 A → 2002-09-04 (-22d) |  | 100% → 0% | none → 169d |  |  |
| 27 | pago planos definitivos ta | 2002-10-09 A → 2002-09-18 (-21d) | 2002-10-10 A → 2002-09-18 (-22d) |  | 100% → 0% | none → 159d |  |  |
| 28 | pago entrega ta | 2002-11-13 → 2002-10-22 (-22d) | 2002-11-14 → 2002-10-22 (-23d) |  |  | 121.42d → 135d |  |  |
| 29 | pago satisfactorio ta | 2002-12-04 → 2002-11-13 (-21d) | 2002-12-05 → 2002-11-13 (-22d) |  |  | 106.42d → 120d |  |  |
| 30 | Suministro equipos eléctricos | 2002-08-13 A → 2002-07-02 (-42d) | 2002-11-06 → 2002-09-24 (-43d) |  | 95% → 0% | 38.96d → 60d | 11FS+30d → 11 |  |
| 31 | pago entrega planos ee | 2002-09-09 A → 2002-07-26 (-45d) | 2002-09-09 A → 2002-07-26 (-45d) |  | 100% → 0% | none → 196d |  |  |
| 32 | pago planos definitivos ee | 2002-09-25 A → 2002-08-13 (-43d) | 2002-09-25 A → 2002-08-13 (-43d) |  | 100% → 0% | none → 184d |  |  |
| 33 | pago entrega ee | 2002-11-06 → 2002-09-24 (-43d) | 2002-11-06 → 2002-09-24 (-43d) |  |  | 127.05d → 155d |  |  |
| 34 | pago satisfactorio ee | 2002-11-27 → 2002-10-15 (-43d) | 2002-11-27 → 2002-10-15 (-43d) |  |  | 112.05d → 140d |  |  |
| 35 | Suministro instrumentación y sist. Control | 2002-07-02 A → 2002-07-02 | 2002-09-10 A → 2002-09-10 |  | 100% → 0% | none → 70d |  |  |
| 36 | pago entrega planos isc | 2002-07-23 A → 2002-07-23 | 2002-07-23 A → 2002-07-23 |  | 100% → 0% | none → 199d |  |  |
| 37 | pago planos definitivos isc | 2002-08-06 A → 2002-08-06 | 2002-08-06 A → 2002-08-06 |  | 100% → 0% | none → 189d |  |  |
| 38 | pago entrega isc | 2002-09-10 A → 2002-09-10 | 2002-09-10 A → 2002-09-10 |  | 100% → 0% | none → 165d |  |  |
| 39 | pago satisfactorio isc | 2002-10-01 A → 2002-10-01 | 2002-10-01 A → 2002-10-01 |  | 100% → 0% | none → 150d |  |  |
| 40 | **CONSTRUCCION Y MONTAJE** |  | 2003-02-21 → 2003-02-18 (-3d) | 218d → 215d | 62% → 6% | 54.05d → 55d |  |  |
| 41 | Dirección de construcción |  | 2003-02-21 → 2003-02-18 (-3d) | 218d → 215d | 65% → 6% | 54.05d → 55d |  |  |
| 42 | Explanación y construcción cimentaciones |  | 2002-06-17 A → 2002-05-27 (-21d) | 45d → 30d | 100% → 40% | none → 85d |  |  |
| 43 | Construcción estructura edificio | 2002-06-18 A → 2002-05-28 (-21d) | 2002-10-08 A → 2002-08-05 (-64d) | 65d → 50d | 100% → 0% | none → 140d |  | resources Mano de obra [500%]; Estructuras metalicas [31200 Kg] → Mano de obra [500%]; Estructuras metalicas [24000 Kg] |
| 44 | Cerramientos y acabados | 2002-10-09 A → 2002-08-06 (-64d) | 2002-12-04 → 2002-10-01 (-64d) |  | 43% → 0% | 97.05d → 140d |  |  |
| 45 | Montaje motogeneradores | 2002-10-09 A → 2002-09-25 (-14d) | 2002-11-14 → 2002-10-22 (-23d) | 25.63d → 20d | 66% → 0% |  |  | resources Montadores motogen [1000%]; Mont Mot bis [200%] → Montadores motogen [937.5%] |
| 46 | Montaje tuberías y equipos auxiliares | 2002-11-14 → 2002-10-23 (-22d) | 2003-01-03 → 2002-12-19 (-15d) | 33.33d → 40d |  |  |  | resources Montadores tuberias [1300%]; Mont tub bis [200%] → Montadores tuberias [1250%] |
| 47 | Montaje electricidad e instrumentación | 2003-01-03 → 2002-12-20 (-14d) | 2003-02-21 → 2003-02-18 (-3d) | 33.09d → 40d |  |  |  | resources Montadores elect e inst [1500%]; Mont elect bis [200%] → Montadores elect e inst [1406.2%] |
| 48 | **PRUEBAS Y PUESTA EN SERVICIO** | 2003-01-03 → 2002-12-20 (-14d) | 2003-05-15 → 2003-05-12 (-3d) | 88.09d → 95d |  |  |  |  |
| 49 | Pruebas equipos en vacío | 2003-02-03 → 2003-01-22 (-12d) | 2003-02-24 → 2003-02-11 (-13d) |  |  | 13.09d → 20d |  |  |
| 50 | Pruebas hidraúlicas tuberías y equipos | 2003-01-03 → 2002-12-20 (-14d) | 2003-02-03 → 2003-01-21 (-13d) |  |  | 13.09d → 20d |  |  |
| 51 | Pruebas eléctricas | 2003-02-21 → 2003-02-19 (-2d) | 2003-03-14 → 2003-03-11 (-3d) |  |  |  |  |  |
| 52 | Pruebas instrumentos y sist control | 2003-02-21 → 2003-02-19 (-2d) | 2003-03-14 → 2003-03-11 (-3d) |  |  |  |  |  |
| 53 | Puesta en marcha | 2003-03-14 → 2003-03-12 (-2d) | 2003-04-16 → 2003-04-11 (-5d) |  |  |  |  |  |
| 54 | Puesta en operación | 2003-04-16 → 2003-04-14 (-2d) | 2003-04-30 → 2003-04-25 (-5d) |  |  |  |  |  |
| 55 | Garantías y recepción | 2003-04-30 → 2003-04-28 (-2d) | 2003-05-15 → 2003-05-12 (-3d) |  |  |  |  |  |

## Version 3 (data date 2002-07-31, saved 2001-11-30, file MP Escenario 2-1.mpp)

Last finish 2003-05-12 → 2003-05-26 (+14d). Complete tasks 4 → 11.

Changed:

| ID | Task | Start | Finish | Duration | Complete | Total float | Predecessors |
| --- | --- | --- | --- | --- | --- | --- | --- |
| 1 | **PROYECTO** |  | 2003-05-12 → 2003-05-26 (+14d) | 340d → 350d | 17% → 43% |  |  |
| 2 | Dirección de proyecto 1 |  | 2003-05-12 → 2003-05-26 (+14d) | 340d → 350d | 24% → 42% |  |  |
| 7 | **INGENIERÍA DE DETALLE** |  |  |  | 23% → 97% | 185d → 10d |  |
| 8 | Ing. Detalle estructuras y arquitectura |  | 2002-05-27 A |  | 40% → 100% | 140d → none |  |
| 9 | Ing. Detalle motogeneradores (especs) |  | 2002-06-03 A |  | 23% → 100% | 0d → none |  |
| 10 | Ing. Detalle tuberías y equipos auxiliares | 2002-06-04 A |  |  | 0% → 84% | 0d → 10d |  |
| 11 | Ing. Detalle eléctrica |  | 2002-07-01 A |  | 14% → 100% | 60d → none |  |
| 12 | Ing. Detalle instrumentación y control |  | 2002-07-01 A |  | 14% → 100% | 70d → none |  |
| 14 | **SUMINISTRO** | 2002-06-04 A | 2002-11-13 → 2002-11-27 (+14d) | 115d → 125d | 0% → 21% | 0d → 120d |  |
| 20 | Suministro motogeneradores | 2002-06-04 A | 2002-09-24 → 2002-10-08 (+14d) | 80d → 90d | 0% → 47% |  |  |
| 21 | pago entrega planos m | 2002-07-08 A | 2002-07-08 A |  | 0% → 100% | 210d → none |  |
| 22 | pago planos definitivos m | 2002-07-30 → 2002-08-06 (+7d) | 2002-07-30 → 2002-08-06 (+7d) |  |  | 194d → 199d | 20SS+40d → 20SS+5% |
| 23 | pago entrega m | 2002-09-24 → 2002-10-08 (+14d) | 2002-09-24 → 2002-10-08 (+14d) |  |  |  |  |
| 24 | pago satisfactorio m | 2002-10-15 → 2002-10-29 (+14d) | 2002-10-15 → 2002-10-29 (+14d) |  |  |  |  |
| 30 | Suministro equipos eléctricos | 2002-07-02 → 2002-08-13 (+42d) | 2002-09-24 → 2002-11-06 (+43d) |  |  | 60d → 40d | 11 → 11FS+30d |
| 31 | pago entrega planos ee | 2002-07-26 → 2002-09-09 (+45d) | 2002-07-26 → 2002-09-09 (+45d) |  |  | 196d → 176d |  |
| 32 | pago planos definitivos ee | 2002-08-13 → 2002-09-25 (+43d) | 2002-08-13 → 2002-09-25 (+43d) |  |  | 184d → 164d |  |
| 33 | pago entrega ee | 2002-09-24 → 2002-11-06 (+43d) | 2002-09-24 → 2002-11-06 (+43d) |  |  | 155d → 135d |  |
| 34 | pago satisfactorio ee | 2002-10-15 → 2002-11-27 (+43d) | 2002-10-15 → 2002-11-27 (+43d) |  |  | 140d → 120d |  |
| 35 | Suministro instrumentación y sist. Control | 2002-07-02 A |  |  | 0% → 44% | 70d → 80d |  |
| 36 | pago entrega planos isc | 2002-07-23 A | 2002-07-23 A |  | 0% → 100% | 199d → none |  |
| 40 | **CONSTRUCCION Y MONTAJE** |  | 2003-02-18 → 2003-03-04 (+14d) | 215d → 225d | 6% → 31% |  |  |
| 41 | Dirección de construcción |  | 2003-02-18 → 2003-03-04 (+14d) | 215d → 225d | 6% → 34% |  |  |
| 42 | Explanación y construcción cimentaciones |  | 2002-05-27 → 2002-06-17 A (+21d) | 30d → 45d | 40% → 100% | 85d → none |  |
| 43 | Construcción estructura edificio | 2002-05-28 → 2002-06-18 A (+21d) | 2002-08-05 → 2002-09-10 (+36d) |  | 0% → 44% | 140d → 125d |  |
| 44 | Cerramientos y acabados | 2002-08-06 → 2002-09-11 (+36d) | 2002-10-01 → 2002-11-06 (+36d) |  |  | 140d → 125d |  |
| 45 | Montaje motogeneradores | 2002-09-25 → 2002-10-09 (+14d) | 2002-10-22 → 2002-11-06 (+15d) |  |  |  |  |
| 46 | Montaje tuberías y equipos auxiliares | 2002-10-23 → 2002-11-07 (+15d) | 2002-12-19 → 2003-01-07 (+19d) |  |  |  |  |
| 47 | Montaje electricidad e instrumentación | 2002-12-20 → 2003-01-08 (+19d) | 2003-02-18 → 2003-03-04 (+14d) |  |  |  |  |
| 48 | **PRUEBAS Y PUESTA EN SERVICIO** | 2002-12-20 → 2003-01-08 (+19d) | 2003-05-12 → 2003-05-26 (+14d) |  |  |  |  |
| 49 | Pruebas equipos en vacío | 2003-01-22 → 2003-02-05 (+14d) | 2003-02-11 → 2003-02-25 (+14d) |  |  |  |  |
| 50 | Pruebas hidraúlicas tuberías y equipos | 2002-12-20 → 2003-01-08 (+19d) | 2003-01-21 → 2003-02-04 (+14d) |  |  |  |  |
| 51 | Pruebas eléctricas | 2003-02-19 → 2003-03-05 (+14d) | 2003-03-11 → 2003-03-26 (+15d) |  |  |  |  |
| 52 | Pruebas instrumentos y sist control | 2003-02-19 → 2003-03-05 (+14d) | 2003-03-11 → 2003-03-26 (+15d) |  |  |  |  |
| 53 | Puesta en marcha | 2003-03-12 → 2003-03-31 (+19d) | 2003-04-11 → 2003-04-25 (+14d) |  |  |  |  |
| 54 | Puesta en operación | 2003-04-14 → 2003-04-28 (+14d) | 2003-04-25 → 2003-05-12 (+17d) |  |  |  |  |
| 55 | Garantías y recepción | 2003-04-28 → 2003-05-13 (+15d) | 2003-05-12 → 2003-05-26 (+14d) |  |  |  |  |

## Version 4 (saved 2001-12-01, file MP Escenario 0.mpp)

Last finish 2003-05-26 → 2003-05-05 (-21d). Complete tasks 11 → 0.

Changed:

| ID | Task | Start | Finish | Duration | Complete | Total float | Predecessors | Other |
| --- | --- | --- | --- | --- | --- | --- | --- | --- |
| 1 | **PROYECTO** | 2002-01-02 A → 2002-01-02 | 2003-05-26 → 2003-05-05 (-21d) | 350d → 335d | 43% → 0% |  |  |  |
| 2 | Dirección de proyecto 1 | 2002-01-02 A → 2002-01-02 | 2003-05-26 → 2003-05-05 (-21d) | 350d → 335d | 42% → 0% |  |  |  |
| 3 | **INGENIERÍA** | 2002-01-02 A → 2002-01-02 | 2002-04-19 A → 2002-04-12 (-7d) | 75d → 70d | 100% → 0% | none → 0d |  |  |
| 4 | Ingeniería Básica | 2002-01-02 A → 2002-01-02 | 2002-02-12 A → 2002-02-12 |  | 100% → 0% | none → 0d |  |  |
| 5 | Ingeniería Básica del edificio | 2002-02-13 A → 2002-02-13 | 2002-03-12 A → 2002-03-05 (-7d) | 20d → 15d | 100% → 0% | none → 55d |  |  |
| 6 | Ingeniería de proceso | 2002-02-13 A → 2002-02-13 | 2002-04-19 A → 2002-04-12 (-7d) | 45d → 40d | 100% → 0% | none → 0d |  |  |
| 7 | **INGENIERÍA DE DETALLE** | 2002-03-13 A → 2002-03-06 (-7d) | 2002-08-12 → 2002-08-05 (-7d) |  | 97% → 0% | 10d → 25d |  |  |
| 8 | Ing. Detalle estructuras y arquitectura | 2002-04-15 A → 2002-04-08 (-7d) | 2002-05-27 A → 2002-05-20 (-7d) |  | 100% → 0% | none → 140d |  |  |
| 9 | Ing. Detalle motogeneradores (especs) | 2002-04-22 A → 2002-04-15 (-7d) | 2002-06-03 A → 2002-05-27 (-7d) |  | 100% → 0% | none → 0d |  |  |
| 10 | Ing. Detalle tuberías y equipos auxiliares | 2002-06-04 A → 2002-05-28 (-7d) | 2002-08-12 → 2002-08-05 (-7d) |  | 84% → 0% | 10d → 0d |  |  |
| 11 | Ing. Detalle eléctrica | 2002-04-22 A → 2002-04-15 (-7d) | 2002-07-01 A → 2002-06-10 (-21d) | 50d → 40d | 100% → 0% | none → 70d |  |  |
| 12 | Ing. Detalle instrumentación y control | 2002-04-22 A → 2002-04-15 (-7d) | 2002-07-01 A → 2002-06-24 (-7d) |  | 100% → 0% | none → 70d |  |  |
| 13 | Ing. Detalle explanación y cimentaciones | 2002-03-13 A → 2002-03-06 (-7d) | 2002-04-12 A → 2002-04-05 (-7d) |  | 100% → 0% | none → 55d |  | resources Tecnico civil [50%]; Proy civil 1; Proy civil 2 [37.5%]; Otros gastos [20 up] → Tecnico civil [50%]; Proy civil 1; Proy civil 2 [37.5%] |
| 14 | **SUMINISTRO** | 2002-06-04 A → 2002-05-28 (-7d) | 2002-11-27 → 2002-11-06 (-21d) | 125d → 115d | 21% → 0% | 120d → 0d |  |  |
| 15 | Suministro equipos auxiliares | 2002-08-13 → 2002-08-06 (-7d) | 2002-10-08 → 2002-10-01 (-7d) |  |  | 20d → 10d |  |  |
| 16 | pago entrega planos ea | 2002-08-30 → 2002-08-23 (-7d) | 2002-08-30 → 2002-08-23 (-7d) |  |  | 182d → 172d |  |  |
| 17 | pago planos definitivos ea | 2002-09-11 → 2002-09-04 (-7d) | 2002-09-11 → 2002-09-04 (-7d) |  |  | 174d → 164d |  |  |
| 18 | pago entrega ea | 2002-10-08 → 2002-10-01 (-7d) | 2002-10-08 → 2002-10-01 (-7d) |  |  | 155d → 145d |  |  |
| 19 | pago satisfactorio ea | 2002-10-29 → 2002-10-22 (-7d) | 2002-10-29 → 2002-10-22 (-7d) |  |  | 140d → 130d |  |  |
| 20 | Suministro motogeneradores | 2002-06-04 A → 2002-05-28 (-7d) | 2002-10-08 → 2002-09-17 (-21d) | 90d → 80d | 47% → 0% |  |  |  |
| 21 | pago entrega planos m | 2002-07-08 A → 2002-07-01 (-7d) | 2002-07-08 A → 2002-07-01 (-7d) |  | 100% → 0% | none → 210d |  |  |
| 22 | pago planos definitivos m | 2002-08-06 → 2002-07-23 (-14d) | 2002-08-06 → 2002-07-23 (-14d) |  |  | 199d → 194d | 20SS+5% → 20SS+40d |  |
| 23 | pago entrega m | 2002-10-08 → 2002-09-17 (-21d) | 2002-10-08 → 2002-09-17 (-21d) |  |  |  |  |  |
| 24 | pago satisfactorio m | 2002-10-29 → 2002-10-08 (-21d) | 2002-10-29 → 2002-10-08 (-21d) |  |  |  |  |  |
| 25 | Suministro tuberías y accesorios | 2002-08-13 → 2002-08-06 (-7d) | 2002-10-22 → 2002-10-15 (-7d) |  |  | 10d → 0d |  |  |
| 26 | pago entrega planos ta | 2002-09-04 → 2002-08-28 (-7d) | 2002-09-04 → 2002-08-28 (-7d) |  |  | 179d → 169d |  |  |
| 27 | pago planos definitivos ta | 2002-09-18 → 2002-09-11 (-7d) | 2002-09-18 → 2002-09-11 (-7d) |  |  | 169d → 159d |  |  |
| 28 | pago entrega ta | 2002-10-22 → 2002-10-15 (-7d) | 2002-10-22 → 2002-10-15 (-7d) |  |  | 145d → 135d |  |  |
| 29 | pago satisfactorio ta | 2002-11-13 → 2002-11-06 (-7d) | 2002-11-13 → 2002-11-06 (-7d) |  |  | 130d → 120d |  |  |
| 30 | Suministro equipos eléctricos | 2002-08-13 → 2002-06-11 (-63d) | 2002-11-06 → 2002-09-03 (-64d) |  |  | 40d → 70d | 11FS+30d → 11 |  |
| 31 | pago entrega planos ee | 2002-09-09 → 2002-07-05 (-66d) | 2002-09-09 → 2002-07-05 (-66d) |  |  | 176d → 206d |  |  |
| 32 | pago planos definitivos ee | 2002-09-25 → 2002-07-23 (-64d) | 2002-09-25 → 2002-07-23 (-64d) |  |  | 164d → 194d |  |  |
| 33 | pago entrega ee | 2002-11-06 → 2002-09-03 (-64d) | 2002-11-06 → 2002-09-03 (-64d) |  |  | 135d → 165d |  |  |
| 34 | pago satisfactorio ee | 2002-11-27 → 2002-09-24 (-64d) | 2002-11-27 → 2002-09-24 (-64d) |  |  | 120d → 150d |  |  |
| 35 | Suministro instrumentación y sist. Control | 2002-07-02 A → 2002-06-25 (-7d) | 2002-09-10 → 2002-09-03 (-7d) |  | 44% → 0% | 80d → 70d |  |  |
| 36 | pago entrega planos isc | 2002-07-23 A → 2002-07-16 (-7d) | 2002-07-23 A → 2002-07-16 (-7d) |  | 100% → 0% | none → 199d |  |  |
| 37 | pago planos definitivos isc | 2002-08-06 → 2002-07-30 (-7d) | 2002-08-06 → 2002-07-30 (-7d) |  |  | 199d → 189d |  |  |
| 38 | pago entrega isc | 2002-09-10 → 2002-09-03 (-7d) | 2002-09-10 → 2002-09-03 (-7d) |  |  | 175d → 165d |  |  |
| 39 | pago satisfactorio isc | 2002-10-01 → 2002-09-24 (-7d) | 2002-10-01 → 2002-09-24 (-7d) |  |  | 160d → 150d |  |  |
| 40 | **CONSTRUCCION Y MONTAJE** | 2002-04-15 A → 2002-04-08 (-7d) | 2003-03-04 → 2003-02-11 (-21d) | 225d → 215d | 31% → 0% |  |  |  |
| 41 | Dirección de construcción | 2002-04-15 A → 2002-04-08 (-7d) | 2003-03-04 → 2003-02-11 (-21d) | 225d → 215d | 34% → 0% |  |  |  |
| 42 | Explanación y construcción cimentaciones | 2002-04-15 A → 2002-04-08 (-7d) | 2002-06-17 A → 2002-05-20 (-28d) | 45d → 30d | 100% → 0% | none → 55d |  |  |
| 43 | Construcción estructura edificio | 2002-06-18 A → 2002-05-21 (-28d) | 2002-09-10 → 2002-07-29 (-43d) |  | 44% → 0% | 125d → 140d |  |  |
| 44 | Cerramientos y acabados | 2002-09-11 → 2002-07-30 (-43d) | 2002-11-06 → 2002-09-24 (-43d) |  |  | 125d → 140d |  |  |
| 45 | Montaje motogeneradores | 2002-10-09 → 2002-09-18 (-21d) | 2002-11-06 → 2002-10-15 (-22d) |  |  |  |  |  |
| 46 | Montaje tuberías y equipos auxiliares | 2002-11-07 → 2002-10-16 (-22d) | 2003-01-07 → 2002-12-12 (-26d) |  |  |  |  |  |
| 47 | Montaje electricidad e instrumentación | 2003-01-08 → 2002-12-13 (-26d) | 2003-03-04 → 2003-02-11 (-21d) |  |  |  |  |  |
| 48 | **PRUEBAS Y PUESTA EN SERVICIO** | 2003-01-08 → 2002-12-13 (-26d) | 2003-05-26 → 2003-05-05 (-21d) |  |  |  |  |  |
| 49 | Pruebas equipos en vacío | 2003-02-05 → 2003-01-15 (-21d) | 2003-02-25 → 2003-02-04 (-21d) |  |  |  |  |  |
| 50 | Pruebas hidraúlicas tuberías y equipos | 2003-01-08 → 2002-12-13 (-26d) | 2003-02-04 → 2003-01-14 (-21d) |  |  |  |  |  |
| 51 | Pruebas eléctricas | 2003-03-05 → 2003-02-12 (-21d) | 2003-03-26 → 2003-03-04 (-22d) |  |  |  |  |  |
| 52 | Pruebas instrumentos y sist control | 2003-03-05 → 2003-02-12 (-21d) | 2003-03-26 → 2003-03-04 (-22d) |  |  |  |  |  |
| 53 | Puesta en marcha | 2003-03-31 → 2003-03-05 (-26d) | 2003-04-25 → 2003-04-04 (-21d) |  |  |  |  |  |
| 54 | Puesta en operación | 2003-04-28 → 2003-04-07 (-21d) | 2003-05-12 → 2003-04-18 (-24d) |  |  |  |  |  |
| 55 | Garantías y recepción | 2003-05-13 → 2003-04-21 (-22d) | 2003-05-26 → 2003-05-05 (-21d) |  |  |  |  |  |

## Version 5 (data date 2002-04-30, saved 2001-12-02, file MP Escenario 1-2.mpp)

Last finish 2003-05-05 → 2003-05-12 (+7d). Complete tasks 0 → 4.

Changed:

| ID | Task | Start | Finish | Duration | Complete | Total float | Predecessors | Other |
| --- | --- | --- | --- | --- | --- | --- | --- | --- |
| 1 | **PROYECTO** | 2002-01-02 A | 2003-05-05 → 2003-05-12 (+7d) | 335d → 340d | 0% → 17% |  |  |  |
| 2 | Dirección de proyecto 1 | 2002-01-02 A | 2003-05-05 → 2003-05-12 (+7d) | 335d → 340d | 0% → 24% |  |  |  |
| 3 | **INGENIERÍA** | 2002-01-02 A | 2002-04-12 → 2002-04-19 A (+7d) | 70d → 75d | 0% → 100% | 0d → none |  |  |
| 4 | Ingeniería Básica | 2002-01-02 A | 2002-02-12 A |  | 0% → 100% | 0d → none |  |  |
| 5 | Ingeniería Básica del edificio | 2002-02-13 A | 2002-03-05 → 2002-03-12 A (+7d) | 15d → 20d | 0% → 100% | 55d → none |  |  |
| 6 | Ingeniería de proceso | 2002-02-13 A | 2002-04-12 → 2002-04-19 A (+7d) | 40d → 45d | 0% → 100% | 0d → none |  |  |
| 7 | **INGENIERÍA DE DETALLE** | 2002-03-06 → 2002-03-13 A (+7d) | 2002-08-05 → 2002-08-12 (+7d) |  | 0% → 23% | 25d → 185d |  |  |
| 8 | Ing. Detalle estructuras y arquitectura | 2002-04-08 → 2002-04-15 A (+7d) | 2002-05-20 → 2002-05-27 (+7d) |  | 0% → 40% |  |  |  |
| 9 | Ing. Detalle motogeneradores (especs) | 2002-04-15 → 2002-04-22 A (+7d) | 2002-05-27 → 2002-06-03 (+7d) |  | 0% → 23% |  |  |  |
| 10 | Ing. Detalle tuberías y equipos auxiliares | 2002-05-28 → 2002-06-04 (+7d) | 2002-08-05 → 2002-08-12 (+7d) |  |  |  |  |  |
| 11 | Ing. Detalle eléctrica | 2002-04-15 → 2002-04-22 A (+7d) | 2002-06-10 → 2002-07-01 (+21d) | 40d → 50d | 0% → 14% | 70d → 60d |  |  |
| 12 | Ing. Detalle instrumentación y control | 2002-04-15 → 2002-04-22 A (+7d) | 2002-06-24 → 2002-07-01 (+7d) |  | 0% → 14% |  |  |  |
| 13 | Ing. Detalle explanación y cimentaciones | 2002-03-06 → 2002-03-13 A (+7d) | 2002-04-05 → 2002-04-12 A (+7d) |  | 0% → 100% | 55d → none |  | resources Tecnico civil [50%]; Proy civil 1; Proy civil 2 [37.5%] → Tecnico civil [50%]; Proy civil 1; Proy civil 2 [37.5%]; Otros gastos [20 up] |
| 14 | **SUMINISTRO** | 2002-05-28 → 2002-06-04 (+7d) | 2002-11-06 → 2002-11-27 (+21d) | 115d → 125d |  |  |  |  |
| 15 | Suministro equipos auxiliares | 2002-08-06 → 2002-08-13 (+7d) | 2002-10-01 → 2002-10-08 (+7d) |  |  |  |  |  |
| 16 | pago entrega planos ea | 2002-08-23 → 2002-08-30 (+7d) | 2002-08-23 → 2002-08-30 (+7d) |  |  |  |  |  |
| 17 | pago planos definitivos ea | 2002-09-04 → 2002-09-11 (+7d) | 2002-09-04 → 2002-09-11 (+7d) |  |  |  |  |  |
| 18 | pago entrega ea | 2002-10-01 → 2002-10-08 (+7d) | 2002-10-01 → 2002-10-08 (+7d) |  |  |  |  |  |
| 19 | pago satisfactorio ea | 2002-10-22 → 2002-10-29 (+7d) | 2002-10-22 → 2002-10-29 (+7d) |  |  |  |  |  |
| 20 | Suministro motogeneradores | 2002-05-28 → 2002-06-04 (+7d) | 2002-09-17 → 2002-09-24 (+7d) |  |  |  |  |  |
| 21 | pago entrega planos m | 2002-07-01 → 2002-07-08 (+7d) | 2002-07-01 → 2002-07-08 (+7d) |  |  |  |  |  |
| 22 | pago planos definitivos m | 2002-07-23 → 2002-07-30 (+7d) | 2002-07-23 → 2002-07-30 (+7d) |  |  |  |  |  |
| 23 | pago entrega m | 2002-09-17 → 2002-09-24 (+7d) | 2002-09-17 → 2002-09-24 (+7d) |  |  |  |  |  |
| 24 | pago satisfactorio m | 2002-10-08 → 2002-10-15 (+7d) | 2002-10-08 → 2002-10-15 (+7d) |  |  |  |  |  |
| 25 | Suministro tuberías y accesorios | 2002-08-06 → 2002-08-13 (+7d) | 2002-10-15 → 2002-10-22 (+7d) |  |  |  |  |  |
| 26 | pago entrega planos ta | 2002-08-28 → 2002-09-04 (+7d) | 2002-08-28 → 2002-09-04 (+7d) |  |  |  |  |  |
| 27 | pago planos definitivos ta | 2002-09-11 → 2002-09-18 (+7d) | 2002-09-11 → 2002-09-18 (+7d) |  |  |  |  |  |
| 28 | pago entrega ta | 2002-10-15 → 2002-10-22 (+7d) | 2002-10-15 → 2002-10-22 (+7d) |  |  |  |  |  |
| 29 | pago satisfactorio ta | 2002-11-06 → 2002-11-13 (+7d) | 2002-11-06 → 2002-11-13 (+7d) |  |  |  |  |  |
| 30 | Suministro equipos eléctricos | 2002-06-11 → 2002-08-13 (+63d) | 2002-09-03 → 2002-11-06 (+64d) |  |  | 70d → 30d | 11 → 11FS+30d |  |
| 31 | pago entrega planos ee | 2002-07-05 → 2002-09-09 (+66d) | 2002-07-05 → 2002-09-09 (+66d) |  |  | 206d → 166d |  |  |
| 32 | pago planos definitivos ee | 2002-07-23 → 2002-09-25 (+64d) | 2002-07-23 → 2002-09-25 (+64d) |  |  | 194d → 154d |  |  |
| 33 | pago entrega ee | 2002-09-03 → 2002-11-06 (+64d) | 2002-09-03 → 2002-11-06 (+64d) |  |  | 165d → 125d |  |  |
| 34 | pago satisfactorio ee | 2002-09-24 → 2002-11-27 (+64d) | 2002-09-24 → 2002-11-27 (+64d) |  |  | 150d → 110d |  |  |
| 35 | Suministro instrumentación y sist. Control | 2002-06-25 → 2002-07-02 (+7d) | 2002-09-03 → 2002-09-10 (+7d) |  |  |  |  |  |
| 36 | pago entrega planos isc | 2002-07-16 → 2002-07-23 (+7d) | 2002-07-16 → 2002-07-23 (+7d) |  |  |  |  |  |
| 37 | pago planos definitivos isc | 2002-07-30 → 2002-08-06 (+7d) | 2002-07-30 → 2002-08-06 (+7d) |  |  |  |  |  |
| 38 | pago entrega isc | 2002-09-03 → 2002-09-10 (+7d) | 2002-09-03 → 2002-09-10 (+7d) |  |  |  |  |  |
| 39 | pago satisfactorio isc | 2002-09-24 → 2002-10-01 (+7d) | 2002-09-24 → 2002-10-01 (+7d) |  |  |  |  |  |
| 40 | **CONSTRUCCION Y MONTAJE** | 2002-04-08 → 2002-04-15 A (+7d) | 2003-02-11 → 2003-02-18 (+7d) |  | 0% → 6% |  |  |  |
| 41 | Dirección de construcción | 2002-04-08 → 2002-04-15 A (+7d) | 2003-02-11 → 2003-02-18 (+7d) |  | 0% → 6% |  |  |  |
| 42 | Explanación y construcción cimentaciones | 2002-04-08 → 2002-04-15 A (+7d) | 2002-05-20 → 2002-05-27 (+7d) |  | 0% → 40% | 55d → 85d |  |  |
| 43 | Construcción estructura edificio | 2002-05-21 → 2002-05-28 (+7d) | 2002-07-29 → 2002-08-05 (+7d) |  |  |  |  |  |
| 44 | Cerramientos y acabados | 2002-07-30 → 2002-08-06 (+7d) | 2002-09-24 → 2002-10-01 (+7d) |  |  |  |  |  |
| 45 | Montaje motogeneradores | 2002-09-18 → 2002-09-25 (+7d) | 2002-10-15 → 2002-10-22 (+7d) |  |  |  |  |  |
| 46 | Montaje tuberías y equipos auxiliares | 2002-10-16 → 2002-10-23 (+7d) | 2002-12-12 → 2002-12-19 (+7d) |  |  |  |  |  |
| 47 | Montaje electricidad e instrumentación | 2002-12-13 → 2002-12-20 (+7d) | 2003-02-11 → 2003-02-18 (+7d) |  |  |  |  |  |
| 48 | **PRUEBAS Y PUESTA EN SERVICIO** | 2002-12-13 → 2002-12-20 (+7d) | 2003-05-05 → 2003-05-12 (+7d) |  |  |  |  |  |
| 49 | Pruebas equipos en vacío | 2003-01-15 → 2003-01-22 (+7d) | 2003-02-04 → 2003-02-11 (+7d) |  |  |  |  |  |
| 50 | Pruebas hidraúlicas tuberías y equipos | 2002-12-13 → 2002-12-20 (+7d) | 2003-01-14 → 2003-01-21 (+7d) |  |  |  |  |  |
| 51 | Pruebas eléctricas | 2003-02-12 → 2003-02-19 (+7d) | 2003-03-04 → 2003-03-11 (+7d) |  |  |  |  |  |
| 52 | Pruebas instrumentos y sist control | 2003-02-12 → 2003-02-19 (+7d) | 2003-03-04 → 2003-03-11 (+7d) |  |  |  |  |  |
| 53 | Puesta en marcha | 2003-03-05 → 2003-03-12 (+7d) | 2003-04-04 → 2003-04-11 (+7d) |  |  |  |  |  |
| 54 | Puesta en operación | 2003-04-07 → 2003-04-14 (+7d) | 2003-04-18 → 2003-04-25 (+7d) |  |  |  |  |  |
| 55 | Garantías y recepción | 2003-04-21 → 2003-04-28 (+7d) | 2003-05-05 → 2003-05-12 (+7d) |  |  |  |  |  |

## Version 6 (data date 2003-05-12, saved 2001-12-03, file MP Escenario 4.mpp)

Last finish 2003-05-12 → 2003-05-09 (-3d). Complete tasks 4 → 49.

Changed:

| ID | Task | Start | Finish | Duration | Complete | Total float | Predecessors | Other |
| --- | --- | --- | --- | --- | --- | --- | --- | --- |
| 1 | **PROYECTO** |  | 2003-05-12 → 2003-05-09 A (-3d) | 340d → 339d | 17% → 100% | 0d → none |  |  |
| 2 | Dirección de proyecto 1 |  | 2003-05-12 → 2003-05-09 A (-3d) | 340d → 339d | 24% → 100% | 0d → none |  |  |
| 7 | **INGENIERÍA DE DETALLE** |  | 2002-08-12 A |  | 23% → 100% | 185d → none |  |  |
| 8 | Ing. Detalle estructuras y arquitectura |  | 2002-05-27 A |  | 40% → 100% | 140d → none |  |  |
| 9 | Ing. Detalle motogeneradores (especs) |  | 2002-06-03 A |  | 23% → 100% | 0d → none |  |  |
| 10 | Ing. Detalle tuberías y equipos auxiliares | 2002-06-04 A | 2002-08-12 A |  | 0% → 100% | 0d → none |  |  |
| 11 | Ing. Detalle eléctrica |  | 2002-07-01 A |  | 14% → 100% | 60d → none |  |  |
| 12 | Ing. Detalle instrumentación y control |  | 2002-07-01 A |  | 14% → 100% | 70d → none |  |  |
| 14 | **SUMINISTRO** | 2002-06-04 A | 2002-11-27 → 2002-12-05 A (+8d) | 125d → 130.63d | 0% → 100% | 0d → none |  |  |
| 15 | Suministro equipos auxiliares | 2002-08-13 A | 2002-10-08 A |  | 0% → 100% | 10d → none |  |  |
| 16 | pago entrega planos ea | 2002-08-30 A | 2002-08-30 A |  | 0% → 100% | 172d → none |  |  |
| 17 | pago planos definitivos ea | 2002-09-11 A | 2002-09-11 A |  | 0% → 100% | 164d → none |  |  |
| 18 | pago entrega ea | 2002-10-08 A | 2002-10-08 A |  | 0% → 100% | 145d → none |  |  |
| 19 | pago satisfactorio ea | 2002-10-29 A | 2002-10-29 A |  | 0% → 100% | 130d → none |  |  |
| 20 | Suministro motogeneradores | 2002-06-04 A | 2002-09-24 → 2002-10-08 A (+14d) | 80d → 90d | 0% → 100% | 0d → none |  |  |
| 21 | pago entrega planos m | 2002-07-08 A | 2002-07-08 A |  | 0% → 100% | 210d → none |  |  |
| 22 | pago planos definitivos m | 2002-07-30 → 2002-08-06 A (+7d) | 2002-07-30 → 2002-08-06 A (+7d) |  | 0% → 100% | 194d → none | 20SS+40d → 20SS+5% |  |
| 23 | pago entrega m | 2002-09-24 → 2002-10-08 A (+14d) | 2002-09-24 → 2002-10-08 A (+14d) |  | 0% → 100% | 155d → none |  |  |
| 24 | pago satisfactorio m | 2002-10-15 → 2002-10-29 A (+14d) | 2002-10-15 → 2002-10-29 A (+14d) |  | 0% → 100% | 140d → none |  |  |
| 25 | Suministro tuberías y accesorios | 2002-08-13 → 2002-09-04 A (+22d) | 2002-10-22 → 2002-11-14 A (+23d) |  | 0% → 100% | 0d → none |  | constraint none → as late as possible |
| 26 | pago entrega planos ta | 2002-09-04 → 2002-09-25 A (+21d) | 2002-09-04 → 2002-09-26 A (+22d) |  | 0% → 100% | 169d → none |  |  |
| 27 | pago planos definitivos ta | 2002-09-18 → 2002-10-09 A (+21d) | 2002-09-18 → 2002-10-10 A (+22d) |  | 0% → 100% | 159d → none |  |  |
| 28 | pago entrega ta | 2002-10-22 → 2002-11-13 A (+22d) | 2002-10-22 → 2002-11-14 A (+23d) |  | 0% → 100% | 135d → none |  |  |
| 29 | pago satisfactorio ta | 2002-11-13 → 2002-12-04 A (+21d) | 2002-11-13 → 2002-12-05 A (+22d) |  | 0% → 100% | 120d → none |  |  |
| 30 | Suministro equipos eléctricos | 2002-08-13 A | 2002-11-06 A |  | 0% → 100% | 30d → none |  |  |
| 31 | pago entrega planos ee | 2002-09-09 A | 2002-09-09 A |  | 0% → 100% | 166d → none |  |  |
| 32 | pago planos definitivos ee | 2002-09-25 A | 2002-09-25 A |  | 0% → 100% | 154d → none |  |  |
| 33 | pago entrega ee | 2002-11-06 A | 2002-11-06 A |  | 0% → 100% | 125d → none |  |  |
| 34 | pago satisfactorio ee | 2002-11-27 A | 2002-11-27 A |  | 0% → 100% | 110d → none |  |  |
| 35 | Suministro instrumentación y sist. Control | 2002-07-02 A | 2002-09-10 A |  | 0% → 100% | 70d → none |  |  |
| 36 | pago entrega planos isc | 2002-07-23 A | 2002-07-23 A |  | 0% → 100% | 199d → none |  |  |
| 37 | pago planos definitivos isc | 2002-08-06 A | 2002-08-06 A |  | 0% → 100% | 189d → none |  |  |
| 38 | pago entrega isc | 2002-09-10 A | 2002-09-10 A |  | 0% → 100% | 165d → none |  |  |
| 39 | pago satisfactorio isc | 2002-10-01 A | 2002-10-01 A |  | 0% → 100% | 150d → none |  |  |
| 40 | **CONSTRUCCION Y MONTAJE** |  | 2003-02-18 → 2003-02-21 A (+3d) | 215d → 218d | 6% → 100% | 55d → none |  |  |
| 41 | Dirección de construcción |  | 2003-02-18 → 2003-02-21 A (+3d) | 215d → 218d | 6% → 100% | 55d → none |  |  |
| 42 | Explanación y construcción cimentaciones |  | 2002-05-27 → 2002-06-17 A (+21d) | 30d → 45d | 40% → 100% | 85d → none |  |  |
| 43 | Construcción estructura edificio | 2002-05-28 → 2002-06-18 A (+21d) | 2002-08-05 → 2002-10-08 A (+64d) | 50d → 65d | 0% → 100% | 140d → none |  | resources Mano de obra [500%]; Estructuras metalicas [24000 Kg] → Mano de obra [500%]; Estructuras metalicas [31200 Kg] |
| 44 | Cerramientos y acabados | 2002-08-06 → 2002-10-09 A (+64d) | 2002-10-01 → 2002-12-04 A (+64d) |  | 0% → 100% | 140d → none |  |  |
| 45 | Montaje motogeneradores | 2002-09-25 → 2002-10-09 A (+14d) | 2002-10-22 → 2002-11-14 A (+23d) | 20d → 25.63d | 0% → 100% | 0d → none |  | resources Montadores motogen [937.5%] → Montadores motogen [1000%]; Mont Mot bis [200%] |
| 46 | Montaje tuberías y equipos auxiliares | 2002-10-23 → 2002-11-14 A (+22d) | 2002-12-19 → 2003-01-03 A (+15d) | 40d → 33.33d | 0% → 100% | 0d → none |  | resources Montadores tuberias [1250%] → Montadores tuberias [1300%]; Mont tub bis [200%] |
| 47 | Montaje electricidad e instrumentación | 2002-12-20 → 2003-01-03 A (+14d) | 2003-02-18 → 2003-02-21 A (+3d) | 40d → 33.09d | 0% → 100% | 0d → none |  | resources Montadores elect e inst [1406.2%] → Montadores elect e inst [1500%]; Mont elect bis [200%] |
| 48 | **PRUEBAS Y PUESTA EN SERVICIO** | 2002-12-20 → 2003-01-03 A (+14d) | 2003-05-12 → 2003-05-09 A (-3d) | 95d → 84.39d | 0% → 100% | 0d → none |  |  |
| 49 | Pruebas equipos en vacío | 2003-01-22 → 2003-02-03 A (+12d) | 2003-02-11 → 2003-02-24 A (+13d) |  | 0% → 100% | 20d → none |  |  |
| 50 | Pruebas hidraúlicas tuberías y equipos | 2002-12-20 → 2003-01-03 A (+14d) | 2003-01-21 → 2003-02-03 A (+13d) |  | 0% → 100% | 20d → none |  |  |
| 51 | Pruebas eléctricas | 2003-02-19 → 2003-02-21 A (+2d) | 2003-03-11 → 2003-03-24 A (+13d) | 15d → 20d | 0% → 100% | 0d → none |  | resources Consumos prubas electricas; Operarios [625%] → Consumos prubas electricas [1935.5%]; Operarios [12096.8%] |
| 52 | Pruebas instrumentos y sist control | 2003-02-19 → 2003-02-21 A (+2d) | 2003-03-11 → 2003-03-17 A (+6d) |  | 0% → 100% | 0d → none |  |  |
| 53 | Puesta en marcha | 2003-03-12 → 2003-04-03 A (+22d) | 2003-04-11 → 2003-04-17 A (+6d) | 20d → 10.2d | 0% → 100% | 0d → none |  | resources Personal de operación [625%] → Personal de operación [625%]; Pers oper bis [600%] |
| 54 | Puesta en operación | 2003-04-14 → 2003-04-17 A (+3d) | 2003-04-25 → 2003-04-30 A (+5d) | 10d → 8.9d | 0% → 100% | 0d → none |  | resources Personal de operación [875%] → Personal de operación [875%]; Pers oper bis [600%] |
| 55 | Garantías y recepción | 2003-04-28 → 2003-04-30 A (+2d) | 2003-05-12 → 2003-05-09 A (-3d) | 10d → 6.25d | 0% → 100% | 0d → none |  | resources Personal de operación [1000%] → Personal de operación [1000%]; Pers oper bis [600%] |

## Version 7 (data date 2002-07-31, saved 2001-12-04, file MP Escenario 2-2.mpp)

Last finish 2003-05-09 → 2003-04-30 (-9d). Complete tasks 49 → 11.

Changed:

| ID | Task | Start | Finish | Duration | Complete | Total float | Other |
| --- | --- | --- | --- | --- | --- | --- | --- |
| 1 | **PROYECTO** |  | 2003-05-09 A → 2003-04-30 (-9d) | 339d → 332.05d | 100% → 45% | none → 0d |  |
| 2 | Dirección de proyecto 1 |  | 2003-05-09 A → 2003-04-29 (-10d) | 339d → 332d | 100% → 44% | none → 0.05d |  |
| 7 | **INGENIERÍA DE DETALLE** |  | 2002-08-12 A → 2002-08-12 |  | 100% → 97% | none → 117d |  |
| 10 | Ing. Detalle tuberías y equipos auxiliares |  | 2002-08-12 A → 2002-08-12 |  | 100% → 84% | none → 5.62d |  |
| 14 | **SUMINISTRO** |  | 2002-12-05 A → 2002-11-27 (-8d) | 130.63d → 125d | 100% → 21% | none → 102.05d |  |
| 15 | Suministro equipos auxiliares | 2002-08-13 A → 2002-08-13 | 2002-10-08 A → 2002-10-08 |  | 100% → 0% | none → 15.62d |  |
| 16 | pago entrega planos ea | 2002-08-30 A → 2002-08-30 | 2002-08-30 A → 2002-08-30 |  | 100% → 0% | none → 164.05d |  |
| 17 | pago planos definitivos ea | 2002-09-11 A → 2002-09-11 | 2002-09-11 A → 2002-09-11 |  | 100% → 0% | none → 156.05d |  |
| 18 | pago entrega ea | 2002-10-08 A → 2002-10-08 | 2002-10-08 A → 2002-10-08 |  | 100% → 0% | none → 137.05d |  |
| 19 | pago satisfactorio ea | 2002-10-29 A → 2002-10-29 | 2002-10-29 A → 2002-10-29 |  | 100% → 0% | none → 122.05d |  |
| 20 | Suministro motogeneradores |  | 2002-10-08 A → 2002-10-08 |  | 100% → 47% | none → 0d |  |
| 22 | pago planos definitivos m | 2002-08-06 A → 2002-08-06 | 2002-08-06 A → 2002-08-06 |  | 100% → 0% | none → 181.05d |  |
| 23 | pago entrega m | 2002-10-08 A → 2002-10-08 | 2002-10-08 A → 2002-10-08 |  | 100% → 0% | none → 137.05d |  |
| 24 | pago satisfactorio m | 2002-10-29 A → 2002-10-29 | 2002-10-29 A → 2002-10-29 |  | 100% → 0% | none → 122.05d |  |
| 25 | Suministro tuberías y accesorios | 2002-09-04 A → 2002-08-13 (-22d) | 2002-11-14 A → 2002-10-22 (-23d) |  | 100% → 0% | none → 5.62d | constraint as late as possible → none |
| 26 | pago entrega planos ta | 2002-09-25 A → 2002-09-04 (-21d) | 2002-09-26 A → 2002-09-04 (-22d) |  | 100% → 0% | none → 161.05d |  |
| 27 | pago planos definitivos ta | 2002-10-09 A → 2002-09-18 (-21d) | 2002-10-10 A → 2002-09-18 (-22d) |  | 100% → 0% | none → 151.05d |  |
| 28 | pago entrega ta | 2002-11-13 A → 2002-10-22 (-22d) | 2002-11-14 A → 2002-10-22 (-23d) |  | 100% → 0% | none → 127.05d |  |
| 29 | pago satisfactorio ta | 2002-12-04 A → 2002-11-13 (-21d) | 2002-12-05 A → 2002-11-13 (-22d) |  | 100% → 0% | none → 112.05d |  |
| 30 | Suministro equipos eléctricos | 2002-08-13 A → 2002-08-13 | 2002-11-06 A → 2002-11-06 |  | 100% → 0% | none → 28.96d |  |
| 31 | pago entrega planos ee | 2002-09-09 A → 2002-09-09 | 2002-09-09 A → 2002-09-09 |  | 100% → 0% | none → 158.05d |  |
| 32 | pago planos definitivos ee | 2002-09-25 A → 2002-09-25 | 2002-09-25 A → 2002-09-25 |  | 100% → 0% | none → 146.05d |  |
| 33 | pago entrega ee | 2002-11-06 A → 2002-11-06 | 2002-11-06 A → 2002-11-06 |  | 100% → 0% | none → 117.05d |  |
| 34 | pago satisfactorio ee | 2002-11-27 A → 2002-11-27 | 2002-11-27 A → 2002-11-27 |  | 100% → 0% | none → 102.05d |  |
| 35 | Suministro instrumentación y sist. Control |  | 2002-09-10 A → 2002-09-10 |  | 100% → 44% | none → 86.91d |  |
| 37 | pago planos definitivos isc | 2002-08-06 A → 2002-08-06 | 2002-08-06 A → 2002-08-06 |  | 100% → 0% | none → 181.05d |  |
| 38 | pago entrega isc | 2002-09-10 A → 2002-09-10 | 2002-09-10 A → 2002-09-10 |  | 100% → 0% | none → 157.05d |  |
| 39 | pago satisfactorio isc | 2002-10-01 A → 2002-10-01 | 2002-10-01 A → 2002-10-01 |  | 100% → 0% | none → 142.05d |  |
| 40 | **CONSTRUCCION Y MONTAJE** |  | 2003-02-21 A → 2003-02-07 (-14d) | 218d → 208d | 100% → 34% | none → 54.05d |  |
| 41 | Dirección de construcción |  | 2003-02-21 A → 2003-02-07 (-14d) | 218d → 208d | 100% → 37% | none → 54.05d |  |
| 43 | Construcción estructura edificio |  | 2002-10-08 A → 2002-09-10 (-28d) | 65d → 50d | 100% → 44% | none → 125d | resources Mano de obra [500%]; Estructuras metalicas [31200 Kg] → Mano de obra [500%]; Estructuras metalicas [24000 Kg] |
| 44 | Cerramientos y acabados | 2002-10-09 A → 2002-09-11 (-28d) | 2002-12-04 A → 2002-11-06 (-28d) |  | 100% → 0% | none → 107.05d |  |
| 45 | Montaje motogeneradores | 2002-10-09 A → 2002-10-09 | 2002-11-14 A → 2002-10-30 (-15d) | 25.63d → 15.62d | 100% → 0% | none → 0d |  |
| 46 | Montaje tuberías y equipos auxiliares | 2002-11-14 A → 2002-10-30 (-15d) | 2003-01-03 A → 2002-12-18 (-16d) |  | 100% → 0% | none → 0d |  |
| 47 | Montaje electricidad e instrumentación | 2003-01-03 A → 2002-12-18 (-16d) | 2003-02-21 A → 2003-02-07 (-14d) |  | 100% → 0% | none → 0d |  |
| 48 | **PRUEBAS Y PUESTA EN SERVICIO** | 2003-01-03 A → 2002-12-18 (-16d) | 2003-05-09 A → 2003-04-30 (-9d) | 84.39d → 88.09d | 100% → 0% | none → 0d |  |
| 49 | Pruebas equipos en vacío | 2003-02-03 A → 2003-01-20 (-14d) | 2003-02-24 A → 2003-02-10 (-14d) |  | 100% → 0% | none → 13.09d |  |
| 50 | Pruebas hidraúlicas tuberías y equipos | 2003-01-03 A → 2002-12-18 (-16d) | 2003-02-03 A → 2003-01-20 (-14d) |  | 100% → 0% | none → 13.09d |  |
| 51 | Pruebas eléctricas | 2003-02-21 A → 2003-02-07 (-14d) | 2003-03-24 A → 2003-02-28 (-24d) | 20d → 15d | 100% → 0% | none → 0d | resources Consumos prubas electricas [1935.5%]; Operarios [12096.8%] → Consumos prubas electricas; Operarios [625%] |
| 52 | Pruebas instrumentos y sist control | 2003-02-21 A → 2003-02-07 (-14d) | 2003-03-17 A → 2003-02-28 (-17d) |  | 100% → 0% | none → 0d |  |
| 53 | Puesta en marcha | 2003-04-03 A → 2003-02-28 (-34d) | 2003-04-17 A → 2003-04-02 (-15d) | 10.2d → 20d | 100% → 0% | none → 0d | resources Personal de operación [625%]; Pers oper bis [600%] → Personal de operación [625%] |
| 54 | Puesta en operación | 2003-04-17 A → 2003-04-02 (-15d) | 2003-04-30 A → 2003-04-16 (-14d) | 8.9d → 10d | 100% → 0% | none → 0d | resources Personal de operación [875%]; Pers oper bis [600%] → Personal de operación [875%] |
| 55 | Garantías y recepción | 2003-04-30 A → 2003-04-16 (-14d) | 2003-05-09 A → 2003-04-30 (-9d) | 6.25d → 10d | 100% → 0% | none → 0d | resources Personal de operación [1000%]; Pers oper bis [600%] → Personal de operación [1000%] |
